# plannification_initiale_G1_E

How a schedule from MS Project changed from version to version. A marks actual dates.

## Version 1 (data date 2019-03-20, saved 2019-03-20, file plannification_20-03-19_G1_E.mpp)

| ID | WBS | Task | Duration | Start | Finish | Predecessors | Complete | Total float | Constraint |
| --- | --- | --- | --- | --- | --- | --- | --- | --- | --- |
| 1 | 1 | **Cahier des Charges** | 2.79d | 2019-02-11 A | 2019-02-26 |  | 99% | 0d | start no earlier than 2019-02-11 |
| 2 |  | Analyse de l'existant | 2h | 2019-02-11 A | 2019-02-12 A |  | 100% |  |  |
| 3 | 1.2 | **Fonctionnalités** | 0.86d | 2019-02-11 A | 2019-02-15 A |  | 100% |  |  |
| 4 |  | Module/Sous Parties | 3h | 2019-02-11 A | 2019-02-13 A |  | 100% |  |  |
| 5 |  | Realisation Mockups | 3h | 2019-02-13 A | 2019-02-15 A | 4 | 100% |  |  |
| 6 |  | Spécifications des droits | 1h | 2019-02-13 A | 2019-02-14 A | 4 | 100% |  |  |
| 7 |  | Definitions des contraintes | 1h | 2019-02-15 A | 2019-02-16 A | 2, 3 | 100% |  |  |
| 8 |  | Scénario d'utilisation | 2h | 2019-02-16 A | 2019-02-18 A | 7 | 100% |  |  |
| 9 |  | Redaction Cahier des Charges | 2h | 2019-02-18 A | 2019-02-19 A | 8 | 100% |  |  |
| 10 |  | Rendu cahier des charges | 0h | 2019-02-26 | 2019-02-26 |  |  | 0d | must finish on 2019-02-26 |
| 11 | 2 | **Conception** | 5.86d | 2019-02-27 A | 2019-03-30 | 1 | 71% | 0.14d |  |
| 12 |  | Conception Web | 15h | 2019-02-27 A | 2019-03-11 A |  | 100% |  |  |
| 13 |  | Conception BD 1 | 15h | 2019-02-27 A | 2019-03-11 A |  | 100% |  |  |
| 14 |  | Conception PHP | 15h | 2019-03-11 A | 2019-03-22 | 13, 12 | 55% | 0.43d |  |
| 15 |  | Validation MCD 1 | 0h | 2019-03-21 | 2019-03-21 |  |  | 0d | must start on 2019-03-21 |
| 16 |  | Conception BD 2 | 6h | 2019-03-22 | 2019-03-27 | 15, 14 |  | 0.43d |  |
| 17 |  | Validation MCD 2 | 0h | 2019-03-28 | 2019-03-28 | 15 |  | 0d | must start on 2019-03-28 |
| 18 |  | Réalisation du Dossier de Conception | 3h | 2019-03-27 | 2019-03-29 | 12, 16 |  | 0.43d |  |
| 19 |  | Rendu dossier de conception | 0h | 2019-03-30 | 2019-03-30 |  |  | 0d | must finish on 2019-03-30 |
| 20 | 3 | **Développement** | 8.5d | 2019-04-01 | 2019-05-17 | 11 |  | 0.14d |  |
| 21 | 3.1 | **Developpement Page Web** | 3.43d | 2019-04-01 | 2019-04-18 |  |  | 0.14d |  |
| 22 |  | HTML | 24h | 2019-04-01 | 2019-04-18 |  |  | 0.14d |  |
| 23 |  | CSS | 24h | 2019-04-01 | 2019-04-18 |  |  | 0.14d |  |
| 24 |  | Developpement BD | 14h | 2019-04-19 | 2019-05-01 | 22, 23 |  | 1.71d |  |
| 25 |  | Developpement PHP | 25h | 2019-04-19 | 2019-05-09 | 21 |  | 0.14d |  |
| 26 | 3.4 | **Phase de test** | 1.5d | 2019-05-09 | 2019-05-17 | 21, 24, 25 |  | 0.14d |  |
| 27 |  | Description des scénarios de test | 2.5h | 2019-05-09 | 2019-05-11 |  |  | 0.14d |  |
| 28 |  | Correction de bugs | 8h | 2019-05-11 | 2019-05-17 | 27 |  | 0.14d |  |
| 29 |  | Preparation Soutenance | 5.5h | 2019-05-17 | 2019-05-22 | 20 |  | 0.14d |  |
| 30 |  | Soutenance | 0h | 2019-05-23 | 2019-05-23 |  |  | 0d | must start on 2019-05-23 |

## Version 2 (data date 2019-04-10, saved 2019-04-10, file plannification_10-04-19_G1_E.mpp)

Last finish stays 2019-05-23. Complete tasks 9 → 12.

Changed:

| ID | Task | Start | Finish | Duration | Complete | Total float |
| --- | --- | --- | --- | --- | --- | --- |
| 11 | **Conception** |  |  |  | 71% → 99% | 0.14d → 0d |
| 14 | Conception PHP |  | 2019-03-22 A |  | 55% → 100% | 0.43d → none |
| 16 | Conception BD 2 | 2019-03-22 A | 2019-03-27 → 2019-03-25 A (-2d) | 6h → 3h | 0% → 100% | 0.43d → none |
| 18 | Réalisation du Dossier de Conception | 2019-03-27 A | 2019-03-29 A |  | 0% → 100% | 0.43d → none |
| 20 | **Développement** | 2019-04-01 A |  |  | 0% → 14% |  |
| 21 | **Developpement Page Web** | 2019-04-01 A |  |  | 0% → 28% |  |
| 22 | HTML | 2019-04-01 A |  |  | 0% → 26% |  |
| 23 | CSS | 2019-04-01 A |  |  | 0% → 30% |  |

## Version 3 (data date 2019-05-16, saved 2019-05-16, file plannification_16-05-19_G1_E.mpp)

Last finish stays 2019-05-23. Complete tasks 12 → 20.

Changed:

| ID | Task | Start | Finish | Duration | Complete | Total float |
| --- | --- | --- | --- | --- | --- | --- |
| 1 | **Cahier des Charges** |  | 2019-02-26 A |  | 99% → 100% | 0d → none |
| 10 | Rendu cahier des charges | 2019-02-26 A | 2019-02-26 A | 0h → 1.5h | 0% → 100% | 0d → none |
| 11 | **Conception** |  | 2019-03-30 A |  | 99% → 100% | 0d → none |
| 15 | Validation MCD 1 | 2019-03-21 A | 2019-03-21 A | 0h → 1.5h | 0% → 100% | 0d → none |
| 17 | Validation MCD 2 | 2019-03-28 A | 2019-03-28 A | 0h → 1.5h | 0% → 100% | 0d → none |
| 19 | Rendu dossier de conception | 2019-03-30 A | 2019-03-30 A | 0h → 1.5h | 0% → 100% | 0d → none |
| 20 | **Développement** |  |  |  | 14% → 91% |  |
| 21 | **Developpement Page Web** |  | 2019-04-18 A |  | 28% → 100% | 0.14d → none |
| 22 | HTML |  | 2019-04-18 A |  | 26% → 100% | 0.14d → none |
| 23 | CSS |  | 2019-04-18 A |  | 30% → 100% | 0.14d → none |
| 24 | Developpement BD | 2019-04-19 A | 2019-05-01 A |  | 0% → 100% | 1.71d → none |
| 25 | Developpement PHP | 2019-04-19 A | 2019-05-09 A |  | 0% → 100% | 0.14d → none |
| 26 | **Phase de test** | 2019-05-09 A |  |  | 0% → 18% |  |
| 27 | Description des scénarios de test | 2019-05-09 A |  |  | 0% → 75% |  |
